# Project Lifecycle

How a schedule from MS Project changed from version to version. A marks actual dates.

## Version 1 (saved 2017-08-14, file Project Lifecycle_3.mpp)

| ID | WBS | Task | Duration | Start | Finish | Total float |
| --- | --- | --- | --- | --- | --- | --- |
| 1 | 1 | **Define the project** | 1d | 2017-08-01 | 2017-08-01 | 0d |
| 2 |  | Create and negotiate definition documents | 1d | 2017-08-01 | 2017-08-01 |  |
| 3 |  | Create and publish project announcement | 1d | 2017-08-01 | 2017-08-01 |  |
| 4 |  | Assemble and organize project team | 1d | 2017-08-01 | 2017-08-01 |  |
| 5 |  | Control Gate: Planning | 1d | 2017-08-01 | 2017-08-01 |  |
| 6 | 2 | **Plan the project** | 1d | 2017-08-01 | 2017-08-01 | 0d |
| 7 |  | Create tasks and organize per definition documents | 1d | 2017-08-01 | 2017-08-01 |  |
| 8 |  | Sequence tasks and estimate durations | 1d | 2017-08-01 | 2017-08-01 |  |
| 9 |  | Identify resources and assign to tasks | 1d | 2017-08-01 | 2017-08-01 |  |
| 10 |  | Level resources and get buy off from management | 1d | 2017-08-01 | 2017-08-01 |  |
| 11 |  | Control Gate: Begin Work | 1d | 2017-08-01 | 2017-08-01 |  |
| 12 | 3 | **Conduct project work and reviews** | 1d | 2017-08-01 | 2017-08-01 | 0d |
| 13 |  | Conduct work cycle 1 | 1d | 2017-08-01 | 2017-08-01 |  |
| 14 |  | Review for quality 1 | 1d | 2017-08-01 | 2017-08-01 |  |
| 15 |  | Conduct work cycle 2 | 1d | 2017-08-01 | 2017-08-01 |  |
| 16 |  | Review for quality 2 | 1d | 2017-08-01 | 2017-08-01 |  |
| 17 |  | Conduct work cycle 3 | 1d | 2017-08-01 | 2017-08-01 |  |
| 18 |  | Review for quality 3 | 1d | 2017-08-01 | 2017-08-01 |  |
| 19 |  | Control Gate: Close and Document | 1d | 2017-08-01 | 2017-08-01 |  |
| 20 | 4 | **Project close out and documentation** | 1d | 2017-08-01 | 2017-08-01 | 0d |
| 21 |  | Close project books | 1d | 2017-08-01 | 2017-08-01 |  |
| 22 |  | Release resources to management | 1d | 2017-08-01 | 2017-08-01 |  |
| 23 |  | Prepare final report | 1d | 2017-08-01 | 2017-08-01 |  |
| 24 |  | Post Mortem meeting with management | 1d | 2017-08-01 | 2017-08-01 |  |
| 25 |  | Post Mortem meeting with team. | 1d | 2017-08-01 | 2017-08-01 |  |

## Version 2 (saved 2017-08-14, file Project Lifecycle_5.mpp)

Last finish 2017-08-01 → 2017-09-27 (+57d).

Changed:

| ID | Task | Start | Finish | Duration | Total float | Predecessors |
| --- | --- | --- | --- | --- | --- | --- |
| 1 | **Define the project** |  | 2017-08-01 → 2017-08-10 (+9d) | 1d → 8d |  |  |
| 2 | Create and negotiate definition documents |  | 2017-08-01 → 2017-08-03 (+2d) | 1d → 3d | none → 0d |  |
| 3 | Create and publish project announcement | 2017-08-01 → 2017-08-04 (+3d) | 2017-08-01 → 2017-08-10 (+9d) | 1d → 5d | none → 0d | none → 2 |
| 4 | Assemble and organize project team | 2017-08-01 → 2017-08-07 (+6d) | 2017-08-01 → 2017-08-07 (+6d) |  | none → 0d | none → 3SS+1d |
| 5 | Control Gate: Planning | 2017-08-01 → 2017-08-07 (+6d) | 2017-08-01 → 2017-08-07 (+6d) | 1d → 0d | none → 0d | none → 4 |
| 6 | **Plan the project** | 2017-08-01 → 2017-08-08 (+7d) | 2017-08-01 → 2017-08-16 (+15d) | 1d → 7d |  |  |
| 7 | Create tasks and organize per definition documents | 2017-08-01 → 2017-08-08 (+7d) | 2017-08-01 → 2017-08-08 (+7d) |  | none → 0d | none → 5 |
| 8 | Sequence tasks and estimate durations | 2017-08-01 → 2017-08-09 (+8d) | 2017-08-01 → 2017-08-11 (+10d) | 1d → 3d | none → 0d | none → 7 |
| 9 | Identify resources and assign to tasks | 2017-08-01 → 2017-08-14 (+13d) | 2017-08-01 → 2017-08-16 (+15d) | 1d → 3d | none → 0d | none → 8 |
| 10 | Level resources and get buy off from management | 2017-08-01 → 2017-08-14 (+13d) | 2017-08-01 → 2017-08-16 (+15d) | 1d → 3d | none → 0d | none → 9FF |
| 11 | Control Gate: Begin Work | 2017-08-01 → 2017-08-16 (+15d) | 2017-08-01 → 2017-08-16 (+15d) | 1d → 0d | none → 0d | none → 10 |
| 12 | **Conduct project work and reviews** | 2017-08-01 → 2017-08-17 (+16d) | 2017-08-01 → 2017-09-20 (+50d) | 1d → 24d |  |  |
| 13 | Conduct work cycle 1 | 2017-08-01 → 2017-08-17 (+16d) | 2017-08-01 → 2017-08-25 (+24d) | 1d → 7d | none → 0d | none → 11 |
| 14 | Review for quality 1 | 2017-08-01 → 2017-08-28 (+27d) | 2017-08-01 → 2017-08-28 (+27d) |  | none → 0d | none → 13 |
| 15 | Conduct work cycle 2 | 2017-08-01 → 2017-08-29 (+28d) | 2017-08-01 → 2017-09-07 (+37d) | 1d → 7d | none → 0d | none → 14 |
| 16 | Review for quality 2 | 2017-08-01 → 2017-09-08 (+38d) | 2017-08-01 → 2017-09-08 (+38d) |  | none → 0d | none → 15 |
| 17 | Conduct work cycle 3 | 2017-08-01 → 2017-09-11 (+41d) | 2017-08-01 → 2017-09-19 (+49d) | 1d → 7d | none → 0d | none → 16 |
| 18 | Review for quality 3 | 2017-08-01 → 2017-09-20 (+50d) | 2017-08-01 → 2017-09-20 (+50d) |  | none → 0d | none → 17 |
| 19 | Control Gate: Close and Document | 2017-08-01 → 2017-09-20 (+50d) | 2017-08-01 → 2017-09-20 (+50d) | 1d → 0d | none → 0d | none → 18 |
| 20 | **Project close out and documentation** | 2017-08-01 → 2017-09-21 (+51d) | 2017-08-01 → 2017-09-27 (+57d) | 1d → 5d |  |  |
| 21 | Close project books | 2017-08-01 → 2017-09-21 (+51d) | 2017-08-01 → 2017-09-21 (+51d) |  | none → 0d | none → 19 |
| 22 | Release resources to management | 2017-08-01 → 2017-09-22 (+52d) | 2017-08-01 → 2017-09-22 (+52d) |  | none → 0d | none → 21 |
| 23 | Prepare final report | 2017-08-01 → 2017-09-25 (+55d) | 2017-08-01 → 2017-09-25 (+55d) |  | none → 0d | none → 22 |
| 24 | Post Mortem meeting with management | 2017-08-01 → 2017-09-26 (+56d) | 2017-08-01 → 2017-09-26 (+56d) |  | none → 0d | none → 23 |
| 25 | Post Mortem meeting with team. | 2017-08-01 → 2017-09-27 (+57d) | 2017-08-01 → 2017-09-27 (+57d) |  | none → 0d | none → 24 |

## Version 3 (saved 2017-08-14, file Project Lifecycle_4.mpp)

Last finish 2017-09-27 → 2017-08-09 (-49d).

Changed:

| ID | Task | Start | Finish | Duration | Total float | Predecessors | Other |
| --- | --- | --- | --- | --- | --- | --- | --- |
| 1 | **Define the project** |  | 2017-08-10 → 2017-08-07 (-3d) | 8d → 5d | 0d → 2d |  | baseline start none → 2017-06-05; baseline finish none → 2017-06-15 |
| 2 | Create and negotiate definition documents |  |  |  | 0d → 4d |  | baseline start none → 2017-06-05; baseline finish none → 2017-06-07 |
| 3 | Create and publish project announcement | 2017-08-04 → 2017-08-01 (-3d) | 2017-08-10 → 2017-08-07 (-3d) |  | 0d → 2d | 2 → none | baseline start none → 2017-06-08; baseline finish none → 2017-06-14 |
| 4 | Assemble and organize project team | 2017-08-07 → 2017-08-01 (-6d) | 2017-08-07 → 2017-08-01 (-6d) |  | 0d → 6d | 3SS+1d → none | baseline start none → 2017-06-15; baseline finish none → 2017-06-15 |
| 5 | Control Gate: Planning | 2017-08-07 → 2017-08-01 (-6d) | 2017-08-07 → 2017-08-01 (-6d) |  | 0d → 7d | 4 → none | baseline start none → 2017-06-15; baseline finish none → 2017-06-15 |
| 6 | **Plan the project** | 2017-08-08 → 2017-08-01 (-7d) | 2017-08-16 → 2017-08-03 (-13d) | 7d → 3d | 0d → 4d |  | baseline start none → 2017-06-16; baseline finish none → 2017-06-28 |
| 7 | Create tasks and organize per definition documents | 2017-08-08 → 2017-08-01 (-7d) | 2017-08-08 → 2017-08-01 (-7d) |  | 0d → 6d | 5 → none | baseline start none → 2017-06-16; baseline finish none → 2017-06-16 |
| 8 | Sequence tasks and estimate durations | 2017-08-09 → 2017-08-01 (-8d) | 2017-08-11 → 2017-08-03 (-8d) |  | 0d → 4d | 7 → none | baseline start none → 2017-06-19; baseline finish none → 2017-06-21 |
| 9 | Identify resources and assign to tasks | 2017-08-14 → 2017-08-01 (-13d) | 2017-08-16 → 2017-08-03 (-13d) |  | 0d → 4d | 8 → none | baseline start none → 2017-06-21; baseline finish none → 2017-06-23 |
| 10 | Level resources and get buy off from management | 2017-08-14 → 2017-08-01 (-13d) | 2017-08-16 → 2017-08-03 (-13d) |  | 0d → 4d | 9FF → none | baseline start none → 2017-06-26; baseline finish none → 2017-06-28 |
| 11 | Control Gate: Begin Work | 2017-08-16 → 2017-08-01 (-15d) | 2017-08-16 → 2017-08-01 (-15d) |  | 0d → 7d | 10 → none | baseline start none → 2017-06-28; baseline finish none → 2017-06-28 |
| 12 | **Conduct project work and reviews** | 2017-08-17 → 2017-08-01 (-16d) | 2017-09-20 → 2017-08-09 (-42d) | 24d → 7d |  |  | baseline start none → 2017-06-28; baseline finish none → 2017-08-08 |
| 13 | Conduct work cycle 1 | 2017-08-17 → 2017-08-01 (-16d) | 2017-08-25 → 2017-08-09 (-16d) |  |  | 11 → none | baseline start none → 2017-06-28; baseline finish none → 2017-07-07 |
| 14 | Review for quality 1 | 2017-08-28 → 2017-08-01 (-27d) | 2017-08-28 → 2017-08-01 (-27d) |  | 0d → 6d | 13 → none | baseline start none → 2017-07-07; baseline finish none → 2017-07-10 |
| 15 | Conduct work cycle 2 | 2017-08-29 → 2017-08-01 (-28d) | 2017-09-07 → 2017-08-09 (-29d) |  |  | 14 → none | baseline start none → 2017-07-10; baseline finish none → 2017-07-19 |
| 16 | Review for quality 2 | 2017-09-08 → 2017-08-01 (-38d) | 2017-09-08 → 2017-08-01 (-38d) |  | 0d → 6d | 15 → none | baseline start none → 2017-07-19; baseline finish none → 2017-07-20 |
| 17 | Conduct work cycle 3 | 2017-09-11 → 2017-08-01 (-41d) | 2017-09-19 → 2017-08-09 (-41d) |  |  | 16 → none | baseline start none → 2017-07-20; baseline finish none → 2017-07-31 |
| 18 | Review for quality 3 | 2017-09-20 → 2017-08-01 (-50d) | 2017-09-20 → 2017-08-01 (-50d) |  | 0d → 6d | 17 → none | baseline start none → 2017-07-31; baseline finish none → 2017-08-01 |
| 19 | Control Gate: Close and Document | 2017-09-20 → 2017-08-01 (-50d) | 2017-09-20 → 2017-08-01 (-50d) |  | 0d → 7d | 18 → none | baseline start none → 2017-08-01; baseline finish none → 2017-08-01 |
| 20 | **Project close out and documentation** | 2017-09-21 → 2017-08-01 (-51d) | 2017-09-27 → 2017-08-01 (-57d) | 5d → 1d | 0d → 6d |  | baseline start none → 2017-08-01; baseline finish none → 2017-08-08 |
| 21 | Close project books | 2017-09-21 → 2017-08-01 (-51d) | 2017-09-21 → 2017-08-01 (-51d) |  | 0d → 6d | 19 → none | baseline start none → 2017-08-01; baseline finish none → 2017-08-02 |
| 22 | Release resources to management | 2017-09-22 → 2017-08-01 (-52d) | 2017-09-22 → 2017-08-01 (-52d) |  | 0d → 6d | 21 → none | baseline start none → 2017-08-02; baseline finish none → 2017-08-03 |
| 23 | Prepare final report | 2017-09-25 → 2017-08-01 (-55d) | 2017-09-25 → 2017-08-01 (-55d) |  | 0d → 6d | 22 → none | baseline start none → 2017-08-03; baseline finish none → 2017-08-04 |
| 24 | Post Mortem meeting with management | 2017-09-26 → 2017-08-01 (-56d) | 2017-09-26 → 2017-08-01 (-56d) |  | 0d → 6d | 23 → none | baseline start none → 2017-08-04; baseline finish none → 2017-08-07 |
| 25 | Post Mortem meeting with team. | 2017-09-27 → 2017-08-01 (-57d) | 2017-09-27 → 2017-08-01 (-57d) |  | 0d → 6d | 24 → none | baseline start none → 2017-08-07; baseline finish none → 2017-08-08 |

## Version 4 (saved 2018-06-02, file Project Lifecycle_6.mpp)

Last finish 2017-08-09 → 2017-09-28 (+50d).

Changed:

| ID | Task | Start | Finish | Duration | Total float | Predecessors | Other |
| --- | --- | --- | --- | --- | --- | --- | --- |
| 1 | **Define the project** |  | 2017-08-07 → 2017-08-11 (+4d) | 5d → 9d | 2d → 0d |  | baseline start 2017-06-05 → none; baseline finish 2017-06-15 → none |
| 2 | Create and negotiate definition documents |  |  |  | 4d → 0d |  | resources none → MGT TEAM; PM; QA/QC; baseline start 2017-06-05 → none; baseline finish 2017-06-07 → none |
| 3 | Create and publish project announcement | 2017-08-01 → 2017-08-04 (+3d) | 2017-08-07 → 2017-08-10 (+3d) |  | 2d → 0d | none → 2 | resources none → MGT TEAM; PM; Printer Paper [3 Reams]; baseline start 2017-06-08 → none; baseline finish 2017-06-14 → none |
| 4 | Assemble and organize project team | 2017-08-01 → 2017-08-07 (+6d) | 2017-08-01 → 2017-08-11 (+10d) | 1d → 2d | 6d → 0d | none → 3SS+1d | resources none → MGT TEAM; PM; QA/QC; baseline start 2017-06-15 → none; baseline finish 2017-06-15 → none |
| 5 | Control Gate: Planning | 2017-08-01 → 2017-08-11 (+10d) | 2017-08-01 → 2017-08-11 (+10d) |  | 7d → 0d | none → 4 | baseline start 2017-06-15 → none; baseline finish 2017-06-15 → none |
| 6 | **Plan the project** | 2017-08-01 → 2017-08-14 (+13d) | 2017-08-03 → 2017-08-25 (+22d) | 3d → 10d | 4d → 0d |  | baseline start 2017-06-16 → none; baseline finish 2017-06-28 → none |
| 7 | Create tasks and organize per definition documents | 2017-08-01 → 2017-08-14 (+13d) | 2017-08-01 → 2017-08-14 (+13d) |  | 6d → 0d | none → 5 | resources none → PM; QA/QC; Team [300%]; baseline start 2017-06-16 → none; baseline finish 2017-06-16 → none |
| 8 | Sequence tasks and estimate durations | 2017-08-01 → 2017-08-15 (+14d) | 2017-08-03 → 2017-08-17 (+14d) |  | 4d → 0d | none → 7 | resources none → Team [500%]; baseline start 2017-06-19 → none; baseline finish 2017-06-21 → none |
| 9 | Identify resources and assign to tasks | 2017-08-01 → 2017-08-18 (+17d) | 2017-08-03 → 2017-08-22 (+19d) |  | 4d → 0d | none → 8 | resources none → MGT TEAM [200%]; PM; QA/QC; baseline start 2017-06-21 → none; baseline finish 2017-06-23 → none |
| 10 | Level resources and get buy off from management | 2017-08-01 → 2017-08-23 (+22d) | 2017-08-03 → 2017-08-25 (+22d) |  | 4d → 0d | none → 9FF | resources none → MGT TEAM; PM; baseline start 2017-06-26 → none; baseline finish 2017-06-28 → none |
| 11 | Control Gate: Begin Work | 2017-08-01 → 2017-08-25 (+24d) | 2017-08-01 → 2017-08-25 (+24d) |  | 7d → 0d | none → 10 | baseline start 2017-06-28 → none; baseline finish 2017-06-28 → none |
| 12 | **Conduct project work and reviews** | 2017-08-01 → 2017-08-28 (+27d) | 2017-08-09 → 2017-09-21 (+43d) | 7d → 18d |  |  | baseline start 2017-06-28 → none; baseline finish 2017-08-08 → none |
| 13 | Conduct work cycle 1 | 2017-08-01 → 2017-08-28 (+27d) | 2017-08-09 → 2017-09-06 (+28d) |  |  | none → 11 | resources none → Team [500%]; baseline start 2017-06-28 → none; baseline finish 2017-07-07 → none |
| 14 | Review for quality 1 | 2017-08-01 → 2017-09-07 (+37d) | 2017-08-01 → 2017-09-07 (+37d) |  | 6d → 0d | none → 13 | resources none → QA/QC; baseline start 2017-07-07 → none; baseline finish 2017-07-10 → none |
| 15 | Conduct work cycle 2 | 2017-08-01 → 2017-09-08 (+38d) | 2017-08-09 → 2017-09-08 (+30d) | 7d → 1d |  | none → 14 | resources none → Team [500%]; baseline start 2017-07-10 → none; baseline finish 2017-07-19 → none |
| 16 | Review for quality 2 | 2017-08-01 → 2017-09-11 (+41d) | 2017-08-01 → 2017-09-11 (+41d) |  | 6d → 0d | none → 15 | resources none → QA/QC; baseline start 2017-07-19 → none; baseline finish 2017-07-20 → none |
| 17 | Conduct work cycle 3 | 2017-08-01 → 2017-09-12 (+42d) | 2017-08-09 → 2017-09-20 (+42d) |  |  | none → 16 | resources none → Team [500%]; baseline start 2017-07-20 → none; baseline finish 2017-07-31 → none |
| 18 | Review for quality 3 | 2017-08-01 → 2017-09-21 (+51d) | 2017-08-01 → 2017-09-21 (+51d) |  | 6d → 0d | none → 17 | resources none → QA/QC; baseline start 2017-07-31 → none; baseline finish 2017-08-01 → none |
| 19 | Control Gate: Close and Document | 2017-08-01 → 2017-09-21 (+51d) | 2017-08-01 → 2017-09-21 (+51d) |  | 7d → 0d | none → 18 | baseline start 2017-08-01 → none; baseline finish 2017-08-01 → none |
| 20 | **Project close out and documentation** | 2017-08-01 → 2017-09-22 (+52d) | 2017-08-01 → 2017-09-28 (+58d) | 1d → 5d | 6d → 0d |  | baseline start 2017-08-01 → none; baseline finish 2017-08-08 → none |
| 21 | Close project books | 2017-08-01 → 2017-09-22 (+52d) | 2017-08-01 → 2017-09-22 (+52d) |  | 6d → 0d | none → 19 | resources none → PM; baseline start 2017-08-01 → none; baseline finish 2017-08-02 → none |
| 22 | Release resources to management | 2017-08-01 → 2017-09-25 (+55d) | 2017-08-01 → 2017-09-25 (+55d) |  | 6d → 0d | none → 21 | resources none → PM; baseline start 2017-08-02 → none; baseline finish 2017-08-03 → none |
| 23 | Prepare final report | 2017-08-01 → 2017-09-26 (+56d) | 2017-08-01 → 2017-09-26 (+56d) |  | 6d → 0d | none → 22 | resources none → PM; Printer Paper [2 Reams]; baseline start 2017-08-03 → none; baseline finish 2017-08-04 → none |
| 24 | Post Mortem meeting with management | 2017-08-01 → 2017-09-27 (+57d) | 2017-08-01 → 2017-09-27 (+57d) |  | 6d → 0d | none → 23 | resources none → MGT TEAM; PM; QA/QC; baseline start 2017-08-04 → none; baseline finish 2017-08-07 → none |
| 25 | Post Mortem meeting with team. | 2017-08-01 → 2017-09-28 (+58d) | 2017-08-01 → 2017-09-28 (+58d) |  | 6d → 0d | none → 24 | resources none → Team [500%]; PM; baseline start 2017-08-07 → none; baseline finish 2017-08-08 → none |

## Version 5 (saved 2018-06-02, file Project Lifecycle_7.mpp)

Last finish 2017-09-28 → 2017-10-11 (+13d).

Changed:

| ID | Task | Start | Finish | Duration | Other |
| --- | --- | --- | --- | --- | --- |
| 1 | **Define the project** |  |  |  | baseline start none → 2017-08-01; baseline finish none → 2017-08-11 |
| 2 | Create and negotiate definition documents |  |  |  | baseline start none → 2017-08-01; baseline finish none → 2017-08-03 |
| 3 | Create and publish project announcement |  |  |  | baseline start none → 2017-08-04; baseline finish none → 2017-08-10 |
| 4 | Assemble and organize project team |  |  |  | baseline start none → 2017-08-07; baseline finish none → 2017-08-11 |
| 5 | Control Gate: Planning |  |  |  | baseline start none → 2017-08-11; baseline finish none → 2017-08-11 |
| 6 | **Plan the project** |  |  |  | baseline start none → 2017-08-14; baseline finish none → 2017-08-25 |
| 7 | Create tasks and organize per definition documents |  |  |  | baseline start none → 2017-08-14; baseline finish none → 2017-08-14 |
| 8 | Sequence tasks and estimate durations |  |  |  | baseline start none → 2017-08-15; baseline finish none → 2017-08-17 |
| 9 | Identify resources and assign to tasks |  |  |  | baseline start none → 2017-08-18; baseline finish none → 2017-08-22 |
| 10 | Level resources and get buy off from management |  |  |  | baseline start none → 2017-08-23; baseline finish none → 2017-08-25 |
| 11 | Control Gate: Begin Work |  |  |  | baseline start none → 2017-08-25; baseline finish none → 2017-08-25 |
| 12 | **Conduct project work and reviews** |  | 2017-09-21 → 2017-10-03 (+12d) | 18d → 26d | baseline start none → 2017-08-28; baseline finish none → 2017-09-21 |
| 13 | Conduct work cycle 1 |  | 2017-09-06 → 2017-09-18 (+12d) | 7d → 15d | baseline start none → 2017-08-28; baseline finish none → 2017-09-06 |
| 14 | Review for quality 1 | 2017-09-07 → 2017-09-19 (+12d) | 2017-09-07 → 2017-09-19 (+12d) |  | baseline start none → 2017-09-07; baseline finish none → 2017-09-07 |
| 15 | Conduct work cycle 2 | 2017-09-08 → 2017-09-20 (+12d) | 2017-09-08 → 2017-09-20 (+12d) |  | baseline start none → 2017-09-08; baseline finish none → 2017-09-08 |
| 16 | Review for quality 2 | 2017-09-11 → 2017-09-21 (+10d) | 2017-09-11 → 2017-09-21 (+10d) |  | baseline start none → 2017-09-11; baseline finish none → 2017-09-11 |
| 17 | Conduct work cycle 3 | 2017-09-12 → 2017-09-22 (+10d) | 2017-09-20 → 2017-10-02 (+12d) |  | baseline start none → 2017-09-12; baseline finish none → 2017-09-20 |
| 18 | Review for quality 3 | 2017-09-21 → 2017-10-03 (+12d) | 2017-09-21 → 2017-10-03 (+12d) |  | baseline start none → 2017-09-21; baseline finish none → 2017-09-21 |
| 19 | Control Gate: Close and Document | 2017-09-21 → 2017-10-03 (+12d) | 2017-09-21 → 2017-10-03 (+12d) |  | baseline start none → 2017-09-21; baseline finish none → 2017-09-21 |
| 20 | **Project close out and documentation** | 2017-09-22 → 2017-10-04 (+12d) | 2017-09-28 → 2017-10-11 (+13d) |  | baseline start none → 2017-09-22; baseline finish none → 2017-09-28 |
| 21 | Close project books | 2017-09-22 → 2017-10-04 (+12d) | 2017-09-22 → 2017-10-04 (+12d) |  | baseline start none → 2017-09-22; baseline finish none → 2017-09-22 |
| 22 | Release resources to management | 2017-09-25 → 2017-10-05 (+10d) | 2017-09-25 → 2017-10-05 (+10d) |  | baseline start none → 2017-09-25; baseline finish none → 2017-09-25 |
| 23 | Prepare final report | 2017-09-26 → 2017-10-06 (+10d) | 2017-09-26 → 2017-10-06 (+10d) |  | baseline start none → 2017-09-26; baseline finish none → 2017-09-26 |
| 24 | Post Mortem meeting with management | 2017-09-27 → 2017-10-10 (+13d) | 2017-09-27 → 2017-10-10 (+13d) |  | baseline start none → 2017-09-27; baseline finish none → 2017-09-27 |
| 25 | Post Mortem meeting with team. | 2017-09-28 → 2017-10-11 (+13d) | 2017-09-28 → 2017-10-11 (+13d) |  | baseline start none → 2017-09-28; baseline finish none → 2017-09-28 |

## Version 6 (saved 2018-06-02, file Project Lifecycle_8.mpp)

Last finish 2017-10-11 → 2017-10-16 (+5d). Complete tasks 0 → 16.

Changed:

| ID | Task | Start | Finish | Duration | Complete | Total float | Other |
| --- | --- | --- | --- | --- | --- | --- | --- |
| 1 | **Define the project** | 2017-08-01 A | 2017-08-11 A |  | 0% → 100% | 0d → none |  |
| 2 | Create and negotiate definition documents | 2017-08-01 A | 2017-08-03 A |  | 0% → 100% | 0d → none |  |
| 3 | Create and publish project announcement | 2017-08-04 A | 2017-08-10 A |  | 0% → 100% | 0d → none |  |
| 4 | Assemble and organize project team | 2017-08-07 A | 2017-08-11 A |  | 0% → 100% | 0d → none |  |
| 5 | Control Gate: Planning | 2017-08-11 A | 2017-08-11 A |  | 0% → 100% | 0d → none |  |
| 6 | **Plan the project** | 2017-08-14 A | 2017-08-25 → 2017-08-30 A (+5d) | 10d → 13d | 0% → 100% | 0d → none |  |
| 7 | Create tasks and organize per definition documents | 2017-08-14 A | 2017-08-14 A |  | 0% → 100% | 0d → none |  |
| 8 | Sequence tasks and estimate durations | 2017-08-15 A | 2017-08-17 A |  | 0% → 100% | 0d → none |  |
| 9 | Identify resources and assign to tasks | 2017-08-18 A | 2017-08-22 → 2017-08-29 A (+7d) |  | 0% → 100% | 0d → none |  |
| 10 | Level resources and get buy off from management | 2017-08-23 → 2017-08-28 A (+5d) | 2017-08-25 → 2017-08-30 A (+5d) |  | 0% → 100% | 0d → none | constraint none → start no earlier than 2017-08-25 |
| 11 | Control Gate: Begin Work | 2017-08-25 → 2017-08-30 A (+5d) | 2017-08-25 → 2017-08-30 A (+5d) |  | 0% → 100% | 0d → none |  |
| 12 | **Conduct project work and reviews** | 2017-08-28 → 2017-08-31 A (+3d) | 2017-10-03 → 2017-10-06 A (+3d) |  | 0% → 100% | 0d → none |  |
| 13 | Conduct work cycle 1 | 2017-08-28 → 2017-08-31 A (+3d) | 2017-09-18 → 2017-09-21 A (+3d) |  | 0% → 100% | 0d → none |  |
| 14 | Review for quality 1 | 2017-09-19 → 2017-09-22 A (+3d) | 2017-09-19 → 2017-09-22 A (+3d) |  | 0% → 100% | 0d → none |  |
| 15 | Conduct work cycle 2 | 2017-09-20 → 2017-09-25 A (+5d) | 2017-09-20 → 2017-09-25 A (+5d) |  | 0% → 100% | 0d → none |  |
| 16 | Review for quality 2 | 2017-09-21 → 2017-09-26 A (+5d) | 2017-09-21 → 2017-09-26 A (+5d) |  | 0% → 100% | 0d → none |  |
| 17 | Conduct work cycle 3 | 2017-09-22 → 2017-09-27 A (+5d) | 2017-10-02 → 2017-10-05 A (+3d) |  | 0% → 100% | 0d → none |  |
| 18 | Review for quality 3 | 2017-10-03 → 2017-10-06 A (+3d) | 2017-10-03 → 2017-10-06 A (+3d) |  | 0% → 100% | 0d → none |  |
| 19 | Control Gate: Close and Document | 2017-10-03 → 2017-10-06 A (+3d) | 2017-10-03 → 2017-10-06 A (+3d) |  | 0% → 100% | 0d → none |  |
| 20 | **Project close out and documentation** | 2017-10-04 → 2017-10-10 (+6d) | 2017-10-11 → 2017-10-16 (+5d) |  |  |  |  |
| 21 | Close project books | 2017-10-04 → 2017-10-10 (+6d) | 2017-10-04 → 2017-10-10 (+6d) |  |  |  |  |
| 22 | Release resources to management | 2017-10-05 → 2017-10-11 (+6d) | 2017-10-05 → 2017-10-11 (+6d) |  |  |  |  |
| 23 | Prepare final report | 2017-10-06 → 2017-10-12 (+6d) | 2017-10-06 → 2017-10-12 (+6d) |  |  |  |  |
| 24 | Post Mortem meeting with management | 2017-10-10 → 2017-10-13 (+3d) | 2017-10-10 → 2017-10-13 (+3d) |  |  |  |  |
| 25 | Post Mortem meeting with team. | 2017-10-11 → 2017-10-16 (+5d) | 2017-10-11 → 2017-10-16 (+5d) |  |  |  |  |
